# Squeezing upgrade in aLIGO H1 - 2017

Schedule from GanttProject, 2017-05-29 to 2018-04-19.

## Calendars

- Project calendar: Mon-Fri working; Sat-Sun off.

## Schedule

| ID | WBS | Task | Type | Duration | Start | Finish | Predecessors | Constraint |
| --- | --- | --- | --- | --- | --- | --- | --- | --- |
| 1 | 1 | SHG assembly (can start anytime in optics lab) |  | 71d | 2017-05-29 | 2017-09-04 |  |  |
| 2 | 2 | In-vacuum OFI assembly (can start anytime in optics lab) |  | 71d | 2017-05-29 | 2017-09-04 |  |  |
| 3 | 3 | VOPO SUS assembly (can start anytime in clean lab) |  | 71d | 2017-05-29 | 2017-09-04 |  |  |
| 4 | 4 | **ISCT6 moves to SQZ area in LVEA after O2** |  | 4d | 2017-08-28 | 2017-08-31 |  | start no earlier than 2017-08-28 |
| 5 | 4.1 | Check IFO lock without AS AIR diode |  | 4d | 2017-08-28 | 2017-08-31 |  |  |
| 6 | 5 | Start squeezer table assembly in SQZ bay in LVEA | milestone | 0d | 2017-09-04 | 2017-09-04 |  |  |
| 7 | 6 | **ISCT6 Squeezer assembly in LVEA** |  | 46d | 2017-09-04 | 2017-11-06 |  |  |
| 8 | 6.1 | **Electronics work** |  | 10d | 2017-09-04 | 2017-09-15 |  |  |
| 9 | 6.1.1 | install racks, power supplies and RF distribution |  | 10d | 2017-09-04 | 2017-09-15 |  |  |
| 10 | 6.1.2 | install chassis |  | 10d | 2017-09-04 | 2017-09-15 |  |  |
| 11 | 6.1.3 | pull cables for controls, short-run RF cables |  | 10d | 2017-09-04 | 2017-09-15 |  |  |
| 12 | 6.1.4 | slow control and DAQ checkout |  | 10d | 2017-09-04 | 2017-09-15 |  |  |
| 13 | 6.2 | ISCT6 laser/optical components |  | 46d | 2017-09-04 | 2017-11-06 |  |  |
| 14 | 7 | ISCT6 squeezer table assembly ready | milestone | 0d | 2017-11-07 | 2017-11-07 | 7 |  |
| 15 | 8 | VOPO Suspension test-end TFs |  | 15d | 2017-09-04 | 2017-09-22 |  |  |
| 16 | 9 | **HAM5-HAM6 squeezing path work** |  | 25d | 2017-09-04 | 2017-10-06 |  |  |
| 17 | 9.1 | Install OFI and tip-tilt in HAM5 |  | 15d | 2017-09-04 | 2017-09-22 |  | start no earlier than 2017-09-04 |
| 18 | 9.2 | Install septum window in SQZ path |  | 5d | 2017-09-18 | 2017-09-22 |  |  |
| 19 | 9.3 | Check alignment to HAM6 |  | 10d | 2017-09-25 | 2017-10-06 |  |  |
| 20 | 10 | **Fiber patch cords and feedthroughs** |  | 11d | 2017-10-02 | 2017-10-16 |  |  |
| 21 | 10.1 | Fiber feedthroughs on site | milestone | 0d | 2017-10-02 | 2017-10-02 |  |  |
| 22 | 10.2 | Fiber feedthroughs re-checked on site |  | 11d | 2017-10-02 | 2017-10-16 | 21 |  |
| 23 | 11 | **HAM6 Feed-throughs and viewport** |  | 19d | 2017-10-17 | 2017-11-10 | 20 |  |
| 24 | 11.1 | Procurement and testing |  | 9d | 2017-10-17 | 2017-10-27 |  |  |
| 25 | 11.2 | Feedthrough installation (HAM6 C1 and D4) |  | 10d | 2017-10-30 | 2017-11-10 |  |  |

Notes:
- 6: Terry (ANU) at LLO; laser delivered April 25th
- 7: Requires laser safe area around tables
- 8: Some work can start during O2 Tuesday maintanance/ run measurement close-out

| ID | WBS | Task | Type | Duration | Start | Finish | Predecessors |
| --- | --- | --- | --- | --- | --- | --- | --- |
| 26 | 12 | **VOPO injection platform (VIP)** |  | 31d | 2017-11-06 | 2017-12-18 |  |
| 27 | 12.1 | Siskiyou mounts ready | milestone | 0d | 2017-11-06 | 2017-11-06 |  |
| 28 | 12.2 | VOPO cavity on site | milestone | 0d | 2017-11-06 | 2017-11-06 |  |
| 29 | 12.3 | VIP assembly and alignment in optics lab |  | 31d | 2017-11-06 | 2017-12-18 | 15, 28 |
| 30 | 13 | **Integration** |  | 74d | 2018-01-08 | 2018-04-19 |  |
| 31 | 13.1 | VOPO installation in HAM6 |  | 15d | 2018-01-08 | 2018-01-26 |  |
| 32 | 13.2 | Tip-tilt installation in HAM6 |  | 15d | 2018-01-08 | 2018-01-26 |  |
| 33 | 13.3 | **VOPO lock in air** |  | 45d | 2018-01-29 | 2018-03-30 | 31 |
| 34 | 13.3.1 | Finish assembly SQZT6 |  | 14d | 2018-01-29 | 2018-02-15 |  |
| 35 | 13.3.2 | Lock/OPO CLF |  | 45d | 2018-01-29 | 2018-03-30 |  |
| 36 | 13.3.3 | ISCT6/SQZT6 Slow control interface, DAQ models, basic auto-locker |  | 45d | 2018-01-29 | 2018-03-30 |  |
| 37 | 13.4 | Alignment/mode match check to OMC single bounce (need CLF/SEED beam) |  | 14d | 2018-04-02 | 2018-04-19 | 33 |

Notes:
- 27: in-vac diodes ready by the end of June; Faraday TBC
- 29: Including re-positioning of OPO crystal and check of OPO escape efficiency
